# SUBPROYECTO A4 - PAMPA DEL TORO

Schedule from Primavera P6, 2022-10-01 to 2022-12-09, data date 2022-10-01.

## Calendars

- OHLA: Mon-Sun 07:00-12:00, 13:00-18:00.

## Schedule

| ID | WBS | Activity | Type | Duration | Start | Finish | Predecessors | Planned start | Planned finish | Total float | Free float | Constraint |
| --- | --- | --- | --- | --- | --- | --- | --- | --- | --- | --- | --- | --- |
|  | 1 | **HITOS DEL PROYECTO** |  |  | 2022-10-01 | 2022-11-08 |  |  |  |  |  |  |
| HP.010 |  | HITO DE ACCESO PARA INICIO DE CONSTRUCCIÓN | milestone | 0d | 2022-10-01 | 2022-10-01 |  | 2022-10-26 | 2022-10-26 | 0d |  | start on or after 2022-10-26 |
| HP.020 |  | HITO DE FIN | milestone | 0d | 2022-11-08 | 2022-11-08 | AG.020 | 2022-12-09 | 2022-12-09 | 32d |  | start on or after 2022-12-09 |
|  | 2 | **TRABAJOS PRELIMINARES** |  |  | 2022-10-26 | 2022-12-09 |  |  |  |  |  |  |
| TP. 0.1O |  | GASTOS GENERALES |  | 45d | 2022-10-26 | 2022-12-09 | HP.010 SS |  |  |  |  | start on or after 2022-10-26 |
| TP. 0.20 |  | INSTALACIONES PROVISIONALES |  | 8d | 2022-10-26 | 2022-11-02 | HP.010 SS |  |  |  |  | start on or after 2022-10-26 |
| TP.0.30 |  | SEGURIDAD Y SALUD OCUPACIONAL |  | 40d | 2022-10-31 | 2022-12-09 | TP. 0.20 SS |  |  |  |  | start on or after 2022-10-31 |
| TP.0.40 |  | MOVILIZACIÓN |  | 14d | 2022-10-31 | 2022-11-13 | HP.010 SS |  |  |  |  | start on or after 2022-10-31 |
|  | 3 | **ACTIVIDADES GENERALES** |  |  | 2022-11-05 | 2022-12-09 |  |  |  |  |  |  |
| AC.020 |  | TRANSPORTE DE MATERIAL GRANULAR, ROCA Y MATERIAL EXCEDENTE |  | 28d | 2022-11-05 | 2022-11-09 | D-05: 0.20 SS | 2022-11-05 | 2022-12-02 | 30d | 0d |  |
| AG.020 |  | MANTENIMIENTO DETRANSITO Y SEGURIDAD VIAL |  | 20d | 2022-11-20 | 2022-12-09 | MVE: 0.10 |  |  |  |  | start on or after 2022-11-20 |
|  | 4 | **MEJORAMIENTO DE VIAS EXISTENTES** |  |  | 2022-11-07 | 2022-11-19 |  |  |  |  |  |  |
| MVE: 0.10 |  | MEJORAMIENTO DE VIAS EXISTENTES |  | 13d | 2022-11-07 | 2022-11-19 | TP.0.40 SS |  |  |  |  | start on or after 2022-11-07 |
| MVE: 0.20 |  | DEMOLICIÓN DE ESTRUCTURAS EXISTENTES Y REPOSICIÓN DE TUBERIAS |  | 6d | 2022-11-07 | 2022-11-12 | MVE: 0.10 SS |  |  |  |  | start on or after 2022-11-07 |
|  | 5 | **FRENTE 01** |  |  | 2022-10-31 | 2022-11-22 |  |  |  |  |  |  |
|  | 4.1 | **DIQUE A4-PT-D-05** |  |  | 2022-10-31 | 2022-11-17 |  |  |  |  |  |  |
| D-05: 0.10 |  | LIMPIEZA Y DESBROCE DE TERRENO (D-05) |  | 1d | 2022-10-31 | 2022-10-31 | TP.0.40 SF |  |  |  |  | start on or after 2022-10-31 |
| D-05: 0.20 |  | CORTE DE TERRENO NATURAL (D-05) |  | 2d | 2022-11-01 | 2022-11-02 |  |  |  |  |  | start on or after 2022-11-01 |
| D-05: 0.30 |  | CONTRUCCIÓN DE DIQUE Y ENROCADO(D-05) |  | 10d | 2022-11-08 | 2022-11-17 | MVE: 0.20 SS |  |  |  |  | start on or after 2022-11-08 |
|  | 2 | **REPOSICIÓN DE CAMINO** |  |  | 2022-11-18 | 2022-11-22 |  |  |  |  |  |  |
| RC: 0.10 |  | LIMPIEZA Y DESBROCE DE TERRENO |  | 1d | 2022-11-18 | 2022-11-18 | D-05: 0.30 |  |  |  |  | start on or after 2022-11-18 |
| RC: 0.20 |  | CORTE DE TERRENO NATURAL (RC) |  | 2d | 2022-11-19 | 2022-11-20 | RC: 0.10 |  |  |  |  | start on or after 2022-11-19 |
| RC: 030 |  | AFIRMADO e=0.25m(RC) |  | 2d | 2022-11-21 | 2022-11-22 | RC: 0.20 |  |  |  |  | start on or after 2022-11-21 |
|  | 6 | **FRENTE 02** |  |  | 2022-11-01 | 2022-12-09 |  |  |  |  |  |  |
|  | 1 | **DIQUE A4-PT-D-04** |  |  | 2022-11-01 | 2022-11-08 |  |  |  |  |  |  |
| D-04: 0.10 |  | LIMPIEZA Y DESBROCE DE TERRENO (D-04) |  | 1d | 2022-11-01 | 2022-11-01 | D-05: 0.20 SS |  |  |  |  | start on or after 2022-11-01 |
| D-04: 0.20 |  | CORTE DE TERRENO NATURAL (D-04) |  | 1d | 2022-11-03 | 2022-11-03 | D-05: 0.20 |  |  |  |  | start on or after 2022-11-03 |
| D-04: 0.30 |  | CONSTRUCCIÓN DE DIQUE Y ENROCADO (D-04) |  | 5d | 2022-11-04 | 2022-11-08 | D-04: 0.20 |  |  |  |  | start on or after 2022-11-04 |

| ID | WBS | Activity | Duration | Start | Finish | Predecessors | Constraint |
| --- | --- | --- | --- | --- | --- | --- | --- |
|  | 2 | **DIQUE A4-PT-D-02** |  | 2022-11-02 | 2022-11-10 |  |  |
| D-02: 0.10 |  | LIMPIEZA Y DESBROCE DE TERRENO (D-02) | 1d | 2022-11-02 | 2022-11-02 | D-04: 0.10 | start on or after 2022-11-02 |
| D-02: 0.20 |  | CORTE DE TERRENO NATURAL (D-02) | 1d | 2022-11-04 | 2022-11-04 | D-04: 0.20 | start on or after 2022-11-04 |
| D-02: 0.30 |  | CONSTRUCCIÓN DE DIQUE Y ENROCADO (D-02) | 2d | 2022-11-09 | 2022-11-10 | D-04: 0.30 | start on or after 2022-11-09 |
|  | 3 | **DIQUE A4-PT-D-03** |  | 2022-11-03 | 2022-11-12 |  |  |
| D-03: 0.10 |  | LIMPIEZA Y DESBROCE DE TERRENO (03) | 1d | 2022-11-03 | 2022-11-03 | D-02: 0.10 | start on or after 2022-11-03 |
| D-03: 0.20 |  | CORTE DE TERRENO NATURAL (D-03) | 1d | 2022-11-05 | 2022-11-05 | D-02: 0.20 | start on or after 2022-11-05 |
| D-03: 0.30 |  | COSNTRUCCIÓN DE DIQUE Y ENROCADO (D-03) | 2d | 2022-11-11 | 2022-11-12 | D-02: 0.30 | start on or after 2022-11-11 |
|  | 4 | **DIQUE A4-PT-D-05** |  | 2022-11-04 | 2022-11-20 |  |  |
| D-10 |  | LIMPIEZA Y DESBROCE DE TERRENO (D-05) | 1d | 2022-11-04 | 2022-11-04 | D-03: 0.10 | start on or after 2022-11-04 |
| D-20 |  | CORTE DE TERRENO NATURAL (D-05) | 1d | 2022-11-07 | 2022-11-07 | D-03: 0.20 | start on or after 2022-11-07 |
| D-30 |  | CONSTRUCCIÓN DE DIQUE Y ENROCADO (D-05) | 7d | 2022-11-14 | 2022-11-20 | D-03: 0.30 | start on or after 2022-11-14 |
|  | 5 | **PPROTECCIÓN DEL CAUCE** |  | 2022-11-05 | 2022-12-08 |  |  |
| PC: 0.10 |  | LIMPIEZA Y DESBROCE DE TERRENO (PC) | 1d | 2022-11-05 | 2022-11-05 | D-10 | start on or after 2022-11-05 |
| PC: 0.30 |  | COLOCACIÓN DE ROCA (PC) | 17d | 2022-11-21 | 2022-12-07 | D-30 | start on or after 2022-11-21 |
| PC: 0.20 |  | CORTE DE TERRENO NATURAL (PC) | 1d | 2022-12-08 | 2022-12-08 | D-20 | start on or after 2022-12-08 |
|  | 6 | **CIERRE DE OBRA** |  | 2022-12-08 | 2022-12-09 |  |  |
| CO: 0.10 |  | DESMOVILIZACIÓN | 2d | 2022-12-08 | 2022-12-09 | PC: 0.30, HP.020 SF | start on or after 2022-12-08 |

## Issues

| Issue | Status | Raised | Activity | Notes |
| --- | --- | --- | --- | --- |
| Free Float (days) is 0 on Activity: HP.020 | IS_Open | 2020-08-11 | HP.010 | ? |
| Free Float (days) is 0 on Activity: TP.010 | IS_Open | 2020-08-11 | AC.020 | ? |
| (New Issue) | IS_Open | 2020-06-01 |  | ? |
